# GANTT

How a schedule from MS Project changed from version to version. A marks actual dates.

## Version 1 (data date 2018-04-06, saved 2018-04-10, file GANTT2.mpp)

| ID | WBS | Task | Duration | Start | Finish | Predecessors | Complete | Total float | Constraint |
| --- | --- | --- | --- | --- | --- | --- | --- | --- | --- |
| 1 | 1 | **Multipurpose Urban Equipment** | 70d | 2018-02-28 A | 2018-06-19 |  | 13% | 0d |  |
| 2 | 1.1 | **HLD - High Level Definition** | 3.5d | 2018-02-28 A | 2018-03-05 |  | 79% | 0d |  |
| 3 | 1.1.1 | **Research** | 1.5d | 2018-02-28 A | 2018-03-01 |  | 50% | 2d |  |
| 4 |  | Market Research | 1d | 2018-02-28 A | 2018-02-28 |  | 50% | 2.5d |  |
| 5 |  | Technical Research | 0.5d | 2018-03-01 A | 2018-03-01 |  | 50% | 2d |  |
| 6 | 1.1.2 | **Planning** | 2d | 2018-03-01 A | 2018-03-05 A | 3 | 100% |  |  |
| 7 |  | Task Identification | 0.5d | 2018-03-01 A | 2018-03-01 A |  | 100% |  |  |
| 8 |  | Task Allocation | 0.5d | 2018-03-02 A | 2018-03-02 A | 7 | 100% |  |  |
| 9 |  | Gantt Chart | 1d | 2018-03-02 A | 2018-03-05 A | 8 | 100% |  |  |
| 10 |  | Deliver project plan | 0d | 2018-03-05 A | 2018-03-05 A | 7, 8, 9 | 100% |  |  |
| 11 | 1.2 | **LLD - Low Level Definition** | 8d | 2018-03-05 A | 2018-03-15 | 2 | 89% | 0d |  |
| 12 | 1.2.1 | **BlackBox** | 5d | 2018-03-05 A | 2018-03-12 A |  | 100% |  |  |
| 13 |  | BlackBox Diagrams | 2d | 2018-03-05 A | 2018-03-07 A |  | 100% |  |  |
| 14 |  | Structural Drafts | 3d | 2018-03-07 A | 2018-03-12 A | 13 | 100% |  |  |
| 15 |  | Deliver Blackbox | 0d | 2018-03-12 A | 2018-03-12 A | 13, 14 | 100% |  |  |
| 16 | 1.2.2 | **Detailed Design** | 3d | 2018-03-12 A | 2018-03-15 | 12 | 83% | 0d |  |
| 17 |  | Detailed Schematics | 3d | 2018-03-12 A | 2018-03-15 A |  | 100% |  |  |
| 18 |  | Structural Drawings | 3d | 2018-03-12 A | 2018-03-15 |  | 50% | 0d |  |
| 19 |  | CardBoard Model | 3d | 2018-03-12 A | 2018-03-15 A |  | 100% |  |  |
| 20 |  | Deliver Detailed Design | 0d | 2018-03-15 A | 2018-03-15 | 12, 17, 18, 19 | 50% | 0d |  |
| 21 | 1.3 | **Material & Budget** | 8.5d | 2018-03-15 A | 2018-04-03 | 11 | 86% | 1d |  |
| 22 |  | Selection Material & Components | 5d | 2018-03-15 A | 2018-03-22 A |  | 100% |  |  |
| 23 |  | Cost Calculations | 2d | 2018-04-02 A | 2018-04-03 |  | 50% | 1d |  |
| 24 | 1.4 | **Interim** | 8d | 2018-04-04 A | 2018-04-16 |  | 13% | 3.5d |  |
| 25 |  | Interim Report | 4d | 2018-04-04 | 2018-04-10 |  |  | 1d |  |
| 26 |  | Interim Presentation | 2d | 2018-04-10 A | 2018-04-12 | 25 | 50% | 0.5d |  |
| 27 |  | Upload Interim Deliverables & Send S&P Assessment | 1d | 2018-04-12 | 2018-04-13 | 26 |  | 0.5d |  |
| 28 |  | Interim Presentation Session | 1d | 2018-04-13 | 2018-04-16 | 27 |  | 3.5d |  |
| 29 |  | Selection of Local Providers & Final List of Materials & Components | 1d | 2018-04-16 | 2018-04-17 | 24 |  | 4.5d |  |
| 30 | 1.6 | **Construction** | 21d | 2018-04-17 | 2018-05-23 | 29 |  | 3.5d |  |
| 31 | 1.6.1 | **Hardware** | 21d | 2018-04-17 | 2018-05-23 |  |  | 3.5d |  |
| 32 |  | Sensors | 5d | 2018-04-17 | 2018-04-24 |  |  | 19.5d |  |
| 33 |  | Base | 10d | 2018-04-17 | 2018-05-01 |  |  | 14.5d |  |
| 34 |  | Case | 20d | 2018-04-18 | 2018-05-23 |  |  | 3.5d |  |
| 35 | 1.6.2 | **Software** | 20d | 2018-04-17 | 2018-05-22 |  |  | 4.5d |  |
| 36 |  | Arduino Code | 20d | 2018-04-17 | 2018-05-22 |  |  | 4.5d |  |
| 37 |  | Refined Report | 0d | 2018-02-28 | 2018-02-28 |  |  | 41d |  |
| 38 | 1.8 | **Functional Tests & Results** | 4d | 2018-05-23 | 2018-05-29 | 30 |  | 3.5d |  |
| 39 |  | Unit Testing | 2d | 2018-05-23 | 2018-05-25 |  |  | 3.5d |  |
| 40 |  | Product Testing | 2d | 2018-05-25 | 2018-05-29 | 39 |  | 4.5d |  |
| 41 |  | Corrections | 2d | 2018-05-25 | 2018-05-29 | 39 |  | 3.5d |  |
| 42 | 1.9 | **Upload final report** | 52d | 2018-04-02 | 2018-06-19 | 11 |  | -1d |  |
| 43 |  | Write Report | 49d | 2018-04-02 | 2018-06-14 |  |  | -1d | start no earlier than 2018-04-02 |
| 44 |  | Upload Report | 0d | 2018-06-15 | 2018-06-15 | 43 |  | 0d | must finish on 2018-06-15 |
| 45 |  | Paper | 7.5d | 2018-06-01 | 2018-06-12 | 41 |  | 4d |  |
| 47 |  | Video | 3d | 2018-06-08 | 2018-06-13 | 41 |  | 3.5d |  |
| 48 |  | Evaluation | 1d | 2018-05-29 | 2018-05-30 | 41 |  | 13.5d |  |
| 49 |  | Presentation | 3d | 2018-06-15 | 2018-06-19 | 43 |  | -1d |  |
| 50 |  | Demonstration | 1d | 2018-05-29 | 2018-05-30 | 41 |  | 13.5d |  |
| 51 |  | Manual | 3d | 2018-05-29 | 2018-06-01 | 41 |  | 11.5d |  |
| 52 |  | Upload Other | 0d | 2018-06-18 | 2018-06-18 | 45, 47, 48, 49, 50, 51 |  | -1d | must finish on 2018-06-18 |
| 53 |  | Final Presentation & Assessment | 0d | 2018-02-28 | 2018-02-28 |  |  | 70d |  |
| 54 |  | EPS@ISEP 2018 Closing & Certificate Awarding Session: Hand-in Prototype, CD, printed Report + Poster | 0d | 2018-02-28 | 2018-02-28 |  |  | 70d |  |

## Version 2 (data date 2018-04-20, saved 2018-04-23, file GANTT.mpp)

Last finish stays 2018-06-19. Complete tasks 10 → 22.

Changed:

| ID | Task | Start | Finish | Complete | Total float |
| --- | --- | --- | --- | --- | --- |
| 1 | **Multipurpose Urban Equipment** |  |  | 13% → 26% | 0d → -1d |
| 2 | **HLD - High Level Definition** |  | 2018-03-05 A | 79% → 100% | 0d → none |
| 3 | **Research** |  | 2018-03-01 A | 50% → 100% | 2d → none |
| 4 | Market Research |  | 2018-02-28 A | 50% → 100% | 2.5d → none |
| 5 | Technical Research |  | 2018-03-01 A | 50% → 100% | 2d → none |
| 11 | **LLD - Low Level Definition** |  | 2018-03-15 A | 89% → 100% | 0d → none |
| 16 | **Detailed Design** |  | 2018-03-15 A | 83% → 100% | 0d → none |
| 18 | Structural Drawings |  | 2018-03-15 A | 50% → 100% | 0d → none |
| 20 | Deliver Detailed Design |  | 2018-03-15 A | 50% → 100% | 0d → none |
| 21 | **Material & Budget** |  | 2018-04-03 A | 86% → 100% | 1d → none |
| 23 | Cost Calculations |  | 2018-04-03 A | 50% → 100% | 1d → none |
| 24 | **Interim** |  | 2018-04-16 A | 13% → 100% | 3.5d → none |
| 25 | Interim Report | 2018-04-04 A | 2018-04-10 A | 0% → 100% | 1d → none |
| 26 | Interim Presentation |  | 2018-04-12 A | 50% → 100% | 0.5d → none |
| 27 | Upload Interim Deliverables & Send S&P Assessment | 2018-04-12 A | 2018-04-13 A | 0% → 100% | 0.5d → none |
| 28 | Interim Presentation Session | 2018-04-13 A | 2018-04-16 A | 0% → 100% | 3.5d → none |
| 29 | Selection of Local Providers & Final List of Materials & Components | 2018-04-16 A | 2018-04-17 A | 0% → 100% | 4.5d → none |
| 37 | Refined Report | 2018-02-28 A |  | 0% → 50% |  |
| 42 | **Upload final report** | 2018-04-02 A |  | 0% → 14% |  |
| 43 | Write Report | 2018-04-02 A |  | 0% → 20% |  |
| 53 | Final Presentation & Assessment | 2018-02-28 A | 2018-02-28 A | 0% → 100% | 70d → none |
| 54 | EPS@ISEP 2018 Closing & Certificate Awarding Session: Hand-in Prototype, CD, printed Report + Poster | 2018-02-28 A | 2018-02-28 A | 0% → 100% | 70d → none |

## Version 3 (data date 2018-06-15, saved 2018-06-12, file GANTT.mpp)

Last finish stays 2018-06-19. Complete tasks 22 → 40.

Added:

| ID | Task | Duration | Start | Finish | Predecessors | Resources |
| --- | --- | --- | --- | --- | --- | --- |
| 46 | Leaflet | 5d | 2018-06-01 A | 2018-06-08 A | 41 | Maria [70%] |

Changed:

| ID | Task | Start | Finish | Duration | Complete | Total float | Predecessors | Other |
| --- | --- | --- | --- | --- | --- | --- | --- | --- |
| 1 | **Multipurpose Urban Equipment** |  | 2018-06-19 A |  | 26% → 100% | -1d → none |  |  |
| 30 | **Construction** | 2018-04-17 A | 2018-05-23 A |  | 0% → 100% | 3.5d → none |  |  |
| 31 | **Hardware** | 2018-04-17 A | 2018-05-23 A |  | 0% → 100% | 3.5d → none |  |  |
| 32 | Sensors | 2018-04-17 A | 2018-04-24 A |  | 0% → 100% | 19.5d → none |  |  |
| 33 | Base | 2018-04-17 A | 2018-05-01 A |  | 0% → 100% | 14.5d → none |  |  |
| 34 | Case | 2018-04-18 A | 2018-05-23 A |  | 0% → 100% | 3.5d → none |  | resources Maarten [45%]; Maria [45%]; Wouter [45%] → Maarten [45%]; Wouter [45%]; Damien [45%] |
| 35 | **Software** | 2018-04-17 A | 2018-05-22 A |  | 0% → 100% | 4.5d → none |  |  |
| 36 | Arduino Code | 2018-04-17 A | 2018-05-22 A |  | 0% → 100% | 4.5d → none |  |  |
| 37 | Refined Report |  | 2018-02-28 A |  | 50% → 100% | 41d → none |  |  |
| 38 | **Functional Tests & Results** | 2018-05-23 A | 2018-05-29 A |  | 0% → 100% | 3.5d → none |  |  |
| 39 | Unit Testing | 2018-05-23 A | 2018-05-25 A |  | 0% → 100% | 3.5d → none |  |  |
| 40 | Product Testing | 2018-05-25 A | 2018-05-29 A |  | 0% → 100% | 4.5d → none |  |  |
| 41 | Corrections | 2018-05-25 A | 2018-05-29 A |  | 0% → 100% | 3.5d → none |  |  |
| 42 | **Upload final report** |  | 2018-06-19 A |  | 14% → 100% | -1d → none |  |  |
| 43 | Write Report |  | 2018-06-14 A |  | 20% → 100% | -1d → none |  |  |
| 44 | Upload Report | 2018-06-15 A | 2018-06-15 A |  | 0% → 100% | 0d → none |  |  |
| 45 | Paper | 2018-06-01 A | 2018-06-12 A |  | 0% → 100% | 4d → none |  |  |
| 47 | Video | 2018-06-08 A | 2018-06-13 A |  | 0% → 100% | 3.5d → none |  |  |
| 48 | Evaluation | 2018-05-29 A | 2018-05-30 → 2018-05-29 A (-1d) | 1d → 0.5d | 0% → 100% | 13.5d → none |  |  |
| 49 | Presentation | 2018-06-15 A | 2018-06-19 A |  | 0% → 100% | -1d → none |  |  |
| 50 | Demonstration | 2018-05-29 A | 2018-05-30 A |  | 0% → 100% | 13.5d → none |  |  |
| 51 | Manual | 2018-05-29 → 2018-06-01 A (+3d) | 2018-06-01 A | 3d → 0.5d | 0% → 100% | 11.5d → none |  | constraint none → finish no earlier than 2018-06-15 |
| 52 | Upload Other | 2018-06-18 A | 2018-06-18 A |  | 0% → 100% | -1d → none | 45, 47, 48, 49, 50, 51 → 45, 46, 47, 48, 49, 50, 51 |  |
